Schedule from GanttProject, 2015-01-23 to 2015-04-13.

## Calendars

- Project calendar: Mon-Fri working; Sat-Sun off.

## Resources

| Resource |
| --- |
| Joe |
| Bill |
| Hal |
| Daniel |

## Schedule

| ID | WBS | Task | Type | Duration | Start | Finish | Predecessors | Complete |
| --- | --- | --- | --- | --- | --- | --- | --- | --- |
| 1 | 1 | Initial specs receieved | milestone | 0d | 2015-01-23 | 2015-01-23 |  |  |
| 2 | 2 | Initial quote |  | 1d | 2015-01-23 | 2015-01-23 | 1 | 100% |
| 3 | 3 | Pending PO |  | 5d | 2015-02-04 | 2015-02-10 |  |  |
| 4 | 4 | Pending Duct sketch |  | 10d | 2015-02-04 | 2015-02-17 |  |  |
| 5 | 5 | PO RECEIVED | milestone | 0d | 2015-02-11 | 2015-02-11 | 2, 3 |  |
| 6 | 6 | CREATE PROJECT FOLDER |  | 1d | 2015-02-11 | 2015-02-11 | 5 |  |
| 7 | 7 | FILLOUT IQ FORM |  | 1d | 2015-02-12 | 2015-02-12 | 6 |  |
| 8 | 8 | **REVIEW PROJECT FOLDER** |  | 1d | 2015-02-12 | 2015-02-12 | 6 |  |
| 9 | 8.1 | Voltage documented |  | 1d | 2015-02-12 | 2015-02-12 |  |  |
| 10 | 8.2 | Quotes in place |  | 1d | 2015-02-12 | 2015-02-12 |  |  |
| 11 | 8.3 | RFQ where necessary |  | 1d | 2015-02-12 | 2015-02-12 |  |  |
| 12 | 8.4 | Fill out Sales Review Form |  | 1d | 2015-02-12 | 2015-02-12 |  |  |
| 13 | 8.5 | Identify customizations |  | 1d | 2015-02-12 | 2015-02-12 |  |  |
| 14 | 8.6 | Attach Proj Mgt Progress sheet to Proj Folder |  | 1d | 2015-02-12 | 2015-02-12 |  |  |
| 15 | 8.7 | Clear delivery dates |  | 1d | 2015-02-12 | 2015-02-12 |  |  |
| 16 | 8.8 | Complete Req for Purchase Order form |  | 1d | 2015-02-12 | 2015-02-12 |  |  |
| 17 | 9 | LAYOUT SKETCH |  | 1d | 2015-02-18 | 2015-02-18 | 1, 4 |  |
| 18 | 10 | AIRFLOW CALCULATION |  | 1d | 2015-02-19 | 2015-02-19 | 5, 17 |  |
| 19 | 11 | **DUCT LAYOUT DRAWING** |  | 1d | 2015-02-20 | 2015-02-20 | 18 |  |
| 20 | 11.1 | Review Sales Order Review Checklist |  | 1d | 2015-02-20 | 2015-02-20 |  |  |
| 21 | 12 | CUSTOMER REVIEW LAYOUT |  | 1d | 2015-02-23 | 2015-02-23 | 19 |  |
| 22 | 13 | LAYOUT APPROVED | milestone | 0d | 2015-02-24 | 2015-02-24 | 21 |  |
| 23 | 14 | 1st DEPOSIT RECEIVED |  | 1d | 2015-02-24 | 2015-02-24 | 22 | 100% |
| 24 | 15 | ORDER MATERIAL |  | 1d | 2015-02-25 | 2015-02-25 | 23 |  |
| 25 | 16 | MATERIAL LEAD 4-6wks |  | 25d | 2015-02-26 | 2015-04-01 | 24 |  |
| 26 | 17 | 2nd Deposit received |  | 1d | 2015-02-25 | 2015-02-25 | 23 |  |
| 27 | 18 | Release shipments |  | 1d | 2015-04-02 | 2015-04-02 | 25, 26 |  |
| 28 | 19 | CHECK DELIVERY DATES |  | 1d | 2015-04-02 | 2015-04-02 | 25 |  |
| 29 | 20 | Notify Customer of delivery dates |  | 1d | 2015-04-03 | 2015-04-03 | 28 |  |
| 30 | 21 | SCHEDULE INSTALL |  | 1d | 2015-04-03 | 2015-04-03 | 28 |  |
| 31 | 22 | Create Project Install Folder |  | 1d | 2015-04-06 | 2015-04-06 | 30 |  |
| 32 | 23 | INSTALL |  | 5d | 2015-04-07 | 2015-04-13 | 31 |  |
